# AGILE GO LIVE TASKS

Schedule from MS Project, 2007-10-23 to 2007-10-29.
POSITRON

## Calendars

- 24 Hours: Mon-Sun 00:00-24:00. Exceptions (off unless hours are given): 2007-10-28 08:00-12:00, 13:00-17:00.

## Resources

| Resource |
| --- |
| Marc-Alexndre |
| Ovidiu Plesa |
| Marc-Alexndre Belanger |
| Samy Levy & Claude Brisson |
| Deborah MacDonald |
| Deborah MacDonald and Ovidiu Plesa |
| Mike SuperVille |
| Daniel Fortin and Adrian Nica |
| Doug to Organize All Team Members to Call in. |
| Marc Alexandre Belanger |
| Frank Siluk Call Meeting |
| Frank Siluk |
| Adrian Nica |
| Daniel Fortin |
| Jeff Larivee |
| Louis Rene Beaudoin |
| Zaki Elayoubi |
| Claude Bisson |
| Samy Levy |
| Donna Koussaya |
| Doug Carnegie |
| Mike Superville and Frank Siluk |
| Frank Siluk to Organize |

## Schedule

| ID | WBS | Task | Duration | Start | Finish | Total slack | Constraint | Deadline | Resources | Work |
| --- | --- | --- | --- | --- | --- | --- | --- | --- | --- | --- |
| 1 | 1 | Agile Team Meeting to review Project Plan, Review 3rd dataload validation reports | 0.5d | 2007-10-23 08:00 | 2007-10-23 12:00 | 16d | start no earlier than 2007-10-23 08:00 |  | Frank Siluk | 4h |
| 2 | 2 | Provide data dump from SRVAGILE04 email to Doug Carnegie, Mike Superville, and Frank Siluk | 0.25d | 2007-10-23 08:00 | 2007-10-23 10:00 | 0.88d | start no earlier than 2007-10-23 08:00 | 2007-10-23 17:00 | Marc-Alexndre Belanger | 2h |
| 3 | 3 | Make necessary Modification in respect to Auto Numbering and verify no formating errors exists on screens | 0.25d | 2007-10-23 08:00 | 2007-10-23 10:00 | 16.25d | start no earlier than 2007-10-23 08:00 |  | Doug Carnegie | 2h |
| 4 | 4 | Make sure Backups are working on All Agile Environments review with Mike SuperVille if Required | 0.5d | 2007-10-24 08:00 | 2007-10-24 12:00 | 13d | start no earlier than 2007-10-24 08:00 |  | Marc-Alexndre Belanger | 4h |
| 5 | 5 | Provide Training and Transfer of knowledge to Eric Cholette of PPSS on creating a Data Dump, Running Backups, Installing the Software, Client, Server, Installing a new set of data from a data load. | 0.5d | 2007-10-25 08:00 | 2007-10-25 12:00 | 10d | start no earlier than 2007-10-25 08:00 |  | Marc-Alexndre Belanger | 4h |
| 6 | 6 | Stop All Engineering Changes, ECO's, Hold Back any Pending Changes, Keep Track of What remains to be done. Communcate with Sub-Contractors, Contract Mfg's and Agile Team | 0.25d | 2007-10-25 08:00 | 2007-10-25 10:00 | 10.25d | start no earlier than 2007-10-25 08:00 |  | Samy Levy & Claude Brisson | 2h |
| 7 | 7 | Kick All Users off ManMan System at 4:00pm on Friday Oct 26, 2007 | 0.2d | 2007-10-26 08:00 | 2007-10-26 09:36 | 7.3d | start no earlier than 2007-10-26 08:00 |  | Ovidiu Plesa | 1.6h |
| 8 | 8 | Take a Full Backup of Positron, Pubsafe, Power All Databases | 0.2d | 2007-10-26 08:00 | 2007-10-26 09:36 | 7.3d | start no earlier than 2007-10-26 08:00 |  | Ovidiu Plesa | 1.6h |
| 9 | 9 | Make two sets of Tapes for Archives | 0.2d | 2007-10-26 15:24 | 2007-10-26 17:00 | 6.38d | finish no earlier than 2007-10-26 17:00 |  | Ovidiu Plesa | 1.6h |
| 10 | 10 | Keep All Users off System / Send Messages to User Community | 0.2d | 2007-10-26 15:24 | 2007-10-26 17:00 | 6.38d | finish no earlier than 2007-10-26 17:00 |  | Ovidiu Plesa | 1.6h |
| 11 | 11 | Prepare System for Data Extract, Refresh Files, Master Bom Files, SUPER BOMS PPSS PRODUCTS , MISSINGSPARTS, DB8PARTS, Power-Products Master Boms including Engineering DB's | 0.2d | 2007-10-26 08:00 | 2007-10-26 09:36 | 7.3d | start no earlier than 2007-10-26 08:00 |  | Deborah MacDonald and Ovidiu Plesa | 1.6h |
| 12 | 12 | Run Data Extracts Create (3) Three sets of Files A) Power & Common Part,Boms,AVL's, Mfg, etc. B) PPSS & Common Parts,Boms,AVL's,Mfg's etc. C) PPSS ; POWER and Common Complete Set | 0.2d | 2007-10-26 08:00 | 2007-10-26 09:36 | 7.3d | start no earlier than 2007-10-26 08:00 |  | Ovidiu Plesa | 1.6h |
| 13 | 13 | Send Each of the Above Extract in separate Zipped Files to the Attention of Doug Carnegie, Mike Superville & Frank Siluk | 0.2d | 2007-10-26 08:00 | 2007-10-26 09:36 | 7.3d | start no earlier than 2007-10-26 08:00 |  | Ovidiu Plesa | 1.6h |
| 14 | 14 | J-Squared will confirm they received all required files and begin process of Data-Manipulation and Conversion to Agile data format | 0.2d | 2007-10-26 08:00 | 2007-10-26 09:36 | 7.3d | start no earlier than 2007-10-26 08:00 |  | Mike SuperVille | 1.6h |
| 15 | 15 | Once J-Square encounters certain errors or messages related to the Missing Sub-Classes a spreadsheet will be sent to Daniel Fortin and Adrian Nica for resolution. | 0.2d | 2007-10-27 08:00 | 2007-10-27 09:36 | 4.3d | start no earlier than 2007-10-27 08:00 |  | Mike SuperVille | 1.6h |
| 16 | 16 | Daniel Fortin and Adrian Nica will provide the answers to the Missing Sub-Classes and return them by email to Mike Superville for him to continue his process | 0.2d | 2007-10-27 08:00 | 2007-10-27 09:36 | 4.3d | start no earlier than 2007-10-27 08:00 |  | Daniel Fortin and Adrian Nica | 1.6h |
| 17 | 17 | A Conference call will be setup with a DIAL IN number by Doug Carnegie to provide a status on Saturday at 2:00pm | 0.2d | 2007-10-27 08:00 | 2007-10-27 09:36 | 4.3d | start no earlier than 2007-10-27 08:00 |  | Doug to Organize All Team Members to Call in. | 1.6h |
| 18 | 18 | Estimated time for Positon to receive Agile Dataload Files = Sunday Morning ?? Time ?? (3) Three sets of files will be received as discribed in TASK 16 they will be emailed to Ovidiu Plesa, Marc Alexandre Belanger and Frank Siluk | 0.5d | 2007-10-28 13:00 | 2007-10-28 17:00 | 0d | must finish on 2007-10-28 17:00 |  | Mike SuperVille | 4h |
| 19 | 19 | Once the (3) Files sets are received Marc Alexandre Belanger will proceed to install PPSS's Data on SRVAgile04; Power's Data on SRVAgile05; and The Complete set on one of the VMWARE workstations SRVAgile 01 or 02 | 0.25d | 2007-10-28 15:00 | 2007-10-28 17:00 | 1.5d | finish no earlier than 2007-10-28 17:00 |  | Marc Alexandre Belanger | 2h |
| 20 | 20 | Once the new data is loaded on the producion servers Marc will inform the group by email | 0.2d | 2007-10-28 08:00 | 2007-10-28 09:36 | 2.3d | start no earlier than 2007-10-28 08:00 |  | Marc-Alexndre Belanger | 1.6h |
| 21 | 21 | Team will logon to either PPSS or Power Agile Server and perform a validation to ensure everything is correct and prepare a summary of their findings to be reviewed Monday by the complete Agile Team including consultants? | 0.5d | 2007-10-28 08:00 | 2007-10-28 12:00 | 2d | start no earlier than 2007-10-28 08:00 |  | Adrian Nica; Daniel Fortin; Jeff Larivee; Louis Rene Beaudoin; Zaki Elayoubi; Claude Bisson; Samy Levy; Ovidiu Plesa; Donna Koussaya; Doug Carnegie; Mike Superville and Frank Siluk | 44h |
| 22 | 22 | Monday after a review of the findings, a decision will be taken to GO Live or Not? If YES a signoff document will be completed if No an analysis of what needs to be resolved in oder to go live. | 0.5d | 2007-10-29 08:00 | 2007-10-29 12:00 | 0d | start no earlier than 2007-10-29 08:00 |  | Adrian Nica; Daniel Fortin; Jeff Larivee; Louis Rene Beaudoin; Zaki Elayoubi; Claude Bisson; Samy Levy; Ovidiu Plesa; Donna Koussaya; Doug Carnegie; Mike Superville and Frank Siluk | 44h |
| 24 | 23 | Entertain a Post Mortem 2 weeks from the GO Live Date ON November 12, 2007 | 0.2d | 2007-10-29 08:00 | 2007-10-29 09:36 | 0.3d | start no earlier than 2007-10-29 08:00 |  | Frank Siluk to Organize | 1.6h |
